# Residential Construction

Schedule from MS Project, 2012-04-30 to 2012-11-23, status date 2012-05-02, scheduled back from the finish, A marks actual dates.

## Calendars

- Standard: Mon-Fri 08:00-12:00, 13:00-17:00; Sat-Sun off.

## Resources

| Resource |
| --- |
| Concrete contractor |
| Finish carpentry contractor |
| Fencing contractor |
| Masonry contractor |
| General contractor |
| Architect |
| Owner |
| Mortgage lender |
| Inspector |
| Electric company |
| Site excavation contractor |
| Electric contractor |
| Plumbing contractor |
| Framing contractor |
| Roofing contractor |
| Heating and AC contractor |
| Insulation contractor |
| Drywall contractor |
| Painting contractor |
| Flooring contractor |
| Appliance contractor |
| Landscape contractor |
| Maid service |
| Finishing contractor |

## Schedule

| ID | WBS | Task | Duration | Start | Finish | Remaining | Total slack | Free slack | Constraint |
| --- | --- | --- | --- | --- | --- | --- | --- | --- | --- |
| 1 | 1 | **Timber Frame Addition Construction Schedule** | 150d? | 2012-04-30 A | 2012-11-23 | 149.97d? | 71d | 0d | as late as possible |
| 2 | 1.1 | **Permitting** | 10d? | 2012-04-30 | 2012-05-11 |  | 0d |  | as late as possible |
| 3 | 1.1.1 | Secure DHEC Permit | 4d? | 2012-04-30 | 2012-05-03 |  | 0d |  | finish no later than 2012-05-03 |
| 4 | 1.1.2 | Secure Building Permit | 7d | 2012-05-03 | 2012-05-11 |  | 12d | 0d | finish no later than 2012-05-12 |
| 5 | 1.2 | **Rentals** | 42d? | 2012-05-09 | 2012-07-05 |  | 7d | 0d | as late as possible |
| 6 | 1.2.1 | Portajohn | 1d? | 2012-05-09 | 2012-05-09 |  | 16d | 0d | finish no later than 2012-05-09 |
| 7 | 1.2.2 | Dumpster | 1d? | 2012-05-09 | 2012-05-09 |  | 16d | 0d | finish no later than 2012-05-09 |
| 8 | 1.2.3 | Equipment | 1d? | 2012-07-05 | 2012-07-05 |  | 57d | 0d | start no later than 2012-07-05 |
| 9 | 1.2.4 | **Site Prep** | 14d? | 2012-05-14 | 2012-05-31 |  | 10d | 0d | as late as possible |
| 10 | 1.2.4.1 | Site Layout | 1d? | 2012-05-14 | 2012-05-14 |  | 19d | 0d | start no later than 2012-05-14 |
| 11 | 1.2.4.2 | Tree Clearing | 1d | 2012-05-15 | 2012-05-15 |  | 20d | 0d | finish no later than 2012-05-15 |
| 12 | 1.2.4.3 | Demo | 8d | 2012-05-16 | 2012-05-25 |  | 21d | 0d | finish no later than 2012-05-26 |
| 13 | 1.2.4.4 | Excavation | 6d | 2012-05-24 | 2012-05-31 |  | 27d | 0d | finish no later than 2012-05-31 |
| 14 | 1.2.4.5 | Septic | 3.5d? | 2012-05-25 | 2012-05-30 |  | 28.5d | 0d | finish no later than 2012-05-30 |
| 15 | 1.3 | **Foundation** | 14d? | 2012-06-01 | 2012-06-20 |  | 24d | 0d | as late as possible |
| 16 | 1.3.1 | Prepare Footers | 2d | 2012-06-01 | 2012-06-04 |  | 33d | 0d | finish no later than 2012-06-04 |
| 17 | 1.3.2 | Footer Inspection | 1d? | 2012-06-05 | 2012-06-05 |  | 35d | 0d | finish no later than 2012-06-05 |
| 18 | 1.3.3 | Termite Treatment | 1d? | 2012-06-05 | 2012-06-05 |  | 35d | 0d | finish no later than 2012-06-05 |
| 19 | 1.3.4 | Pour Footers | 1d? | 2012-06-06 | 2012-06-06 |  | 36d | 0d | start no later than 2012-06-06 |
| 20 | 1.3.5 | Lay Block | 6d | 2012-06-08 | 2012-06-15 |  | 38d | 0d | finish no later than 2012-06-15 |
| 21 | 1.3.6 | Foundation Inspection | 1d? | 2012-06-15 | 2012-06-15 |  | 43d | 0d | finish no later than 2012-06-17 |
| 22 | 1.3.7 | Pour Cells | 1d? | 2012-06-18 | 2012-06-18 |  | 44d | 0d | start no later than 2012-06-18 |
| 23 | 1.3.8 | Waterproofing | 2d | 2012-06-19 | 2012-06-20 |  | 45d | 0d | finish no later than 2012-06-20 |
| 24 | 1.4 | **Floor System** | 8d? | 2012-06-21 | 2012-07-02 |  | 38d | 0d | as late as possible |
| 25 | 1.4.1 | Install Sill Plate | 1d? | 2012-06-21 | 2012-06-21 |  | 47d | 0d | start no later than 2012-06-21 |
| 26 | 1.4.2 | Install Floor Trusses | 4.5d | 2012-06-25 | 2012-06-29 |  | 49d | 0d | finish no later than 2012-06-29 |
| 27 | 1.4.3 | Lay floor decking | 1d | 2012-06-29 | 2012-06-29 |  | 53d | 0d | finish no later than 2012-06-29 |
| 28 | 1.4.4 | Complete Floor Framing | 1d | 2012-07-02 | 2012-07-02 |  | 54d | 0d | finish no later than 2012-07-02 |
| 29 | 1.5 | Back Fill and Rough Grading | 3d? | 2012-06-20 | 2012-06-22 |  | 46d | 0d | finish no later than 2012-06-23 |

| ID | WBS | Task | Duration | Start | Finish | Complete | Remaining | Total slack | Free slack | Constraint |
| --- | --- | --- | --- | --- | --- | --- | --- | --- | --- | --- |
| 30 | 1.6 | **Timber Frame Install** | 10d? | 2012-07-02 | 2012-07-13 |  |  | 45d | 0d | as late as possible |
| 31 | 1.6.1 | Assembly | 1d? | 2012-07-02 | 2012-07-02 |  |  | 54d | 0d | finish no later than 2012-07-02 |
| 32 | 1.6.2 | Raising | 1d? | 2012-07-04 | 2012-07-04 |  |  | 56d | 0d | start no later than 2012-07-04 |
| 33 | 1.6.3 | Finish | 1d? | 2012-07-05 | 2012-07-05 |  |  | 57d | 0d | finish no later than 2012-07-05 |
| 34 | 1.6.4 | T&G Decking Install | 6d | 2012-07-06 | 2012-07-13 |  |  | 58d | 0d | finish no later than 2012-07-13 |
| 35 | 1.6.5 | Install Underlayment | 1d | 2012-07-11 | 2012-07-11 |  |  | 61d | 0d | finish no later than 2012-07-11 |
| 36 | 1.7 | **SIP Install** | 6d | 2012-07-16 | 2012-07-23 |  |  | 55d | 0d | as late as possible |
| 37 | 1.7.1 | Walls | 3d | 2012-07-16 | 2012-07-18 |  |  | 64d | 0d | finish no later than 2012-07-18 |
| 38 | 1.7.2 | Roof | 2d | 2012-07-20 | 2012-07-23 |  |  | 68d | 0d | finish no later than 2012-07-23 |
| 39 | 1.8 | **Roof and Rough Framing** | 10d? | 2012-07-23 | 2012-08-03 |  |  | 60d | 0d | as late as possible |
| 40 | 1.8.1 | Install Overbuilt Roof System | 4d | 2012-07-23 | 2012-07-26 |  |  | 69d | 0d | start no later than 2012-07-23 |
| 41 | 1.8.2 | Install Underlayment | 1d | 2012-07-27 | 2012-07-27 |  |  | 73d | 0d | finish no later than 2012-07-29 |
| 42 | 1.8.3 | Install 2x Ground Interior/Exterior Walls | 3.5d | 2012-07-27 | 2012-08-01 |  |  | 73d | 0d | finish no later than 2012-08-01 |
| 43 | 1.8.4 | Install Moisture Barrier | 3d? | 2012-08-01 | 2012-08-03 |  |  | 76d | 0d | finish no later than 2012-08-03 |
| 44 | 1.9 | Firerock fireplace install | 6d | 2012-07-27 | 2012-08-03 |  |  | 73d | 0d | finish no later than 2012-08-05 |
| 45 | 1.10 | Exterior Deck | 5d | 2012-08-06 | 2012-08-10 |  |  | 79d | 0d | finish no later than 2012-08-10 |
| 46 | 1.11 | Install 1st floor windows | 2.5d | 2012-08-07 | 2012-08-09 |  |  | 80d | 0d | finish no later than 2012-08-09 |
| 47 | 1.12 | Hang 1st floor exterior doors | 0.5d | 2012-08-10 | 2012-08-10 |  |  | 83d | 0d | finish no later than 2012-08-10 |
| 48 | 1.13 | **Rough In Building Systems** | 5d? | 2012-08-06 | 2012-08-10 |  |  | 70d | 0d | as late as possible |
| 49 | 1.13.1 | Rough In Plumbing | 3d | 2012-08-06 | 2012-08-08 |  |  | 70d | 0d | finish no later than 2012-08-08 |
| 50 | 1.13.2 | Install H2O Heater | 1d? | 2012-08-07 | 2012-08-07 |  |  | 71d | 0d | finish no later than 2012-08-07 |
| 51 | 1.13.3 | Rough-in Electrical | 5d | 2012-08-06 | 2012-08-10 |  |  | 70d | 0d | finish no later than 2012-08-10 |
| 52 | 1.13.4 | Rough-in HVAC | 2d | 2012-08-07 | 2012-08-08 |  |  | 71d | 0d | finish no later than 2012-08-08 |
| 53 | 1.14 | **Exterior Siding** | 20d? | 2012-08-10 A | 2012-09-06 |  | 19.98d? | 15d | 0d | as late as possible |
| 54 | 1.14.1 | Fascia | 1d? | 2012-08-10 | 2012-08-10 |  |  | 81d | 0d | finish no later than 2012-08-10 |
| 55 | 1.14.2 | Install Roof | 4.5d? | 2012-08-10 A | 2012-08-16 | 1% | 4.46d? | 0d |  | as late as possible |
| 56 | 1.14.3 | Trim | 4.5d? | 2012-08-15 | 2012-08-21 |  |  | 84.5d | 0d | finish no later than 2012-08-22 |
| 57 | 1.14.4 | Soffit | 1d? | 2012-08-24 | 2012-08-24 |  |  | 91d | 0d | finish no later than 2012-08-25 |
| 58 | 1.14.5 | Beveled Siding | 6d? | 2012-08-24 | 2012-08-31 |  |  | 91d | 0d | finish no later than 2012-09-01 |
| 59 | 1.14.6 | Install exterior stone | 9d | 2012-08-23 | 2012-09-04 |  |  | 90d | 0d | finish no later than 2012-09-04 |
| 60 | 1.14.7 | Stone Verneer - Interior | 9d? | 2012-08-23 | 2012-09-04 |  |  | 90d | 0d | finish no later than 2012-09-04 |
| 61 | 1.14.8 | Gutters and Downspouts | 1d? | 2012-09-06 | 2012-09-06 |  |  | 100d | 0d | finish no later than 2012-09-06 |
| 62 | 1.15 | Rough In Inspection | 1d | 2012-08-20 | 2012-08-20 |  |  | 87d | 0d | start no later than 2012-08-20 |

| ID | WBS | Task | Duration | Start | Finish | Predecessors | Total slack | Free slack | Constraint |
| --- | --- | --- | --- | --- | --- | --- | --- | --- | --- |
| 63 | 1.16 | **Insulation** | 2d | 2012-09-02 | 2012-09-04 |  | 90d | 0d | as late as possible |
| 64 | 1.16.1 | Floor | 2d | 2012-09-02 | 2012-09-04 |  | 97d | 0d | start no later than 2012-09-02 |
| 65 | 1.16.2 | Walls | 1d | 2012-09-02 | 2012-09-03 |  | 97d | 0d | start no later than 2012-09-02 |
| 66 | 1.16.3 | Roof | 1d | 2012-09-03 | 2012-09-03 |  | 90d | 0d | finish no later than 2012-09-03 |
| 67 | 1.17 | **Drywall** | 6d? | 2012-09-06 | 2012-09-13 |  | 93d | 0d | as late as possible |
| 68 | 1.17.1 | Hanging | 4.5d? | 2012-09-06 | 2012-09-12 |  | 100d | 0d | finish no later than 2012-09-12 |
| 69 | 1.17.2 | Finish | 2.5d? | 2012-09-11 | 2012-09-13 |  | 103.5d | 0d | finish no later than 2012-09-13 |
| 70 | 1.18 | **Painting and Staining** | 13d | 2012-09-18 | 2012-10-04 |  | 101d | 0d | as late as possible |
| 71 | 1.18.1 | Interior | 12d | 2012-09-18 | 2012-10-03 |  | 101d | 0d | finish no later than 2012-10-03 |
| 72 | 1.18.2 | Exterior | 4d | 2012-10-01 | 2012-10-04 |  | 110d | 0d | finish no later than 2012-10-04 |
| 73 | 1.19 | Tile bath and shower | 6d | 2012-10-05 | 2012-10-12 |  | 114d | 0d | finish no later than 2012-10-13 |
| 74 | 1.20 | Shower Doors | 1d | 2012-10-05 | 2012-10-05 |  | 114d | 0d | finish no later than 2012-10-07 |
| 75 | 1.21 | **Millwork** | 10d | 2012-10-12 | 2012-10-25 |  | 119d | 0d | as late as possible |
| 76 | 1.21.1 | Install Interior Doors | 1d | 2012-10-12 | 2012-10-12 |  | 119d | 0d | finish no later than 2012-10-12 |
| 77 | 1.21.2 | Flooring | 5d | 2012-10-15 | 2012-10-19 |  | 120d | 0d | finish no later than 2012-10-21 |
| 78 | 1.21.3 | Install - master bath and guest cabinets | 1d | 2012-10-22 | 2012-10-22 |  | 125d | 0d | finish no later than 2012-10-22 |
| 79 | 1.21.4 | Interior Trim | 2d | 2012-10-19 | 2012-10-22 |  | 124d | 0d | finish no later than 2012-10-22 |
| 80 | 1.21.5 | Bookcases | 3d | 2012-10-23 | 2012-10-25 |  | 126d | 0d | finish no later than 2012-10-25 |
| 81 | 1.22 | **Final Building Systems** | 13d? | 2012-10-28 | 2012-11-14 |  | 130d | 0d | as late as possible |
| 82 | 1.22.1 | Finished Plumbing Work | 2d | 2012-10-28 | 2012-10-30 |  | 130d | 0d | start no later than 2012-10-28 |
| 83 | 1.22.2 | Install Plumbing Fixtures | 2d | 2012-10-30 | 2012-10-31 |  | 131d | 0d | finish no later than 2012-10-31 |
| 84 | 1.22.3 | HVAC | 3d | 2012-10-31 | 2012-11-02 |  | 132d | 0d | finish no later than 2012-11-02 |
| 85 | 1.22.4 | Electrical | 4d | 2012-11-02 | 2012-11-07 |  | 134d | 0d | finish no later than 2012-11-07 |
| 86 | 1.22.5 | Complete 1st Floor circuits to service panel | 2d | 2012-11-08 | 2012-11-09 |  | 138d | 0d | finish no later than 2012-11-10 |
| 87 | 1.22.6 | Finish Electical Work | 1d? | 2012-11-08 | 2012-11-08 |  | 138d | 0d | finish no later than 2012-11-08 |
| 88 | 1.22.7 | Install Electrical Fixtures | 5d | 2012-11-08 | 2012-11-14 |  | 138d | 0d | finish no later than 2012-11-14 |
| 89 | 1.22.8 | Complete Structural Wiring | 2d | 2012-11-06 | 2012-11-07 |  | 136d | 0d | finish no later than 2012-11-07 |
| 90 | 1.23 | Bathroom Accessories | 1d | 2012-10-28 | 2012-10-29 |  | 130d | 0d | start no later than 2012-10-28 |
| 91 | 1.24 | Install mirrors | 1d | 2012-10-28 | 2012-10-29 |  | 130d | 0d | start no later than 2012-10-28 |
| 92 | 1.25 | Closet Accessories | 1d | 2012-10-31 | 2012-10-31 |  | 132d | 0d | finish no later than 2012-10-31 |
| 93 | 1.26 | Finish Grading and Gravel | 5d | 2012-11-05 | 2012-11-09 |  | 135d | 0d | finish no later than 2012-11-09 |
| 94 | 1.27 | Complete final inspection for CO | 1d | 2012-11-15 | 2012-11-15 |  | 143d | 0d | finish no later than 2012-11-15 |
| 95 | 1.28 | Final Clean Up | 2d | 2012-11-16 | 2012-11-19 |  | 144d | 0d | finish no later than 2012-11-19 |
| 96 | 1.29 | Perform final walk-through inspection | 1d | 2012-11-21 | 2012-11-21 | 94 | 147d | 0d | finish no later than 2012-11-21 |
| 97 | 1.30 | Complete punch list items | 2d | 2012-11-22 | 2012-11-23 |  | 148d | 0d | finish no later than 2012-11-24 |
