# Timber Frame Project

Schedule from MS Project, 2012-08-08 to 2013-01-21.
Microsoft

## Calendars

- Standard: Mon-Fri 08:00-12:00, 13:00-17:00; Sat-Sun off.

## Schedule

| ID | WBS | Task | Duration | Start | Finish | Predecessors | Total slack | Free slack | Constraint |
| --- | --- | --- | --- | --- | --- | --- | --- | --- | --- |
| 1 | 1 | **Timber Frame Project** | 115.5d? | 2012-08-08 | 2013-01-16 |  | 3d |  | start no earlier than 2012-08-08 |
| 2 | 1.1 | **Design/Engineering** | 53d? | 2012-08-10 | 2012-10-23 |  | 10d |  | start no earlier than 2012-08-08 |
| 3 | 1.1.1 | Research and Find Design Team | 8d | 2012-08-10 | 2012-08-21 | 12 | 10d | 0d | start no earlier than 2012-08-07 |
| 4 | 1.1.2 | Contract Designer and Engineer | 10d | 2012-08-22 | 2012-09-04 | 3 | 10d | 0d | start no earlier than 2012-08-19 |
| 5 | 1.1.3 | Conceptual Design | 10d | 2012-09-05 | 2012-09-18 | 4 | 10d | 0d | start no earlier than 2012-09-03 |
| 6 | 1.1.4 | Construction Drawings | 15d | 2012-09-19 | 2012-10-09 | 5 | 10d | 0d | start no earlier than 2012-09-17 |
| 7 | 1.1.5 | Shop Drawings | 10d | 2012-10-10 | 2012-10-23 | 6, 9 | 10d | 4d | start no earlier than 2012-10-08 |
| 8 | 1.1.6 | Compile Timber List | 5d | 2012-09-10 | 2012-09-14 |  | 25d |  | start no earlier than 2012-09-10 |
| 9 | 1.1.7 | Engineering | 25d | 2012-09-03 | 2012-10-05 |  | 10d |  | start no earlier than 2012-09-03 |
| 10 | 1.1.8 | SIP Plan Review | 5d? | 2012-09-24 | 2012-09-28 | 22 | 24d | 11d | start no earlier than 2012-09-24 |
| 11 | 1.2 | **Office Work** | 88d? | 2012-08-08 | 2012-12-07 |  | 10d |  | start no earlier than 2012-08-08 |
| 12 | 1.2.1 | Project Scheduling | 1d | 2012-08-09 | 2012-08-09 | 13 | 10d | 0d | start no earlier than 2012-08-06 |
| 13 | 1.2.2 | Check on Permit Requirements | 1d? | 2012-08-08 | 2012-08-08 |  | 10d | 0d |  |
| 14 | 1.2.3 | Research and Find Timber Suppliers | 1d | 2012-09-28 | 2012-09-28 | 5 | 73.5d | 0d | start no earlier than 2012-09-28 |
| 15 | 1.2.4 | Develop Raising Plan | 5d | 2012-10-01 | 2012-10-05 | 14 | 73.5d | 0d | start no earlier than 2012-09-30 |
| 16 | 1.2.5 | Find Crane | 1d | 2012-10-08 | 2012-10-08 | 15 | 73.5d | 23d | start no earlier than 2012-09-10 |
| 17 | 1.2.6 | Bid Timbers | 5d | 2012-09-17 | 2012-09-21 | 8 | 55d | 0d | start no earlier than 2012-09-16 |
| 18 | 1.2.7 | Order Timbers | 1d | 2012-09-24 | 2012-09-24 | 17 | 55d | 1d | start no earlier than 2012-09-23 |
| 19 | 1.2.8 | Timber Procurement | 23d? | 2012-09-26 | 2012-10-26 | 18 | 54d | 0d | start no earlier than 2012-09-26 |
| 20 | 1.2.9 | Order T&G Decking | 1d | 2012-11-08 | 2012-11-08 |  | 9.5d | 1d | start no earlier than 2012-11-08 |
| 21 | 1.2.10 | T&G Procurement | 20d? | 2012-11-12 | 2012-12-07 | 20 | 8.5d |  | start no earlier than 2012-11-11 |
| 22 | 1.2.11 | Order SIPs | 3d? | 2012-09-19 | 2012-09-21 | 5 | 24d | 0d | start no earlier than 2012-09-17 |
| 23 | 1.2.12 | SIP Procurement | 38d? | 2012-10-16 | 2012-12-06 | 10, 22 | 13d | 9d | start no earlier than 2012-10-16 |
| 24 | 1.2.13 | Order Crane | 1d | 2012-11-09 | 2012-11-09 | 16 | 50.5d |  | start no earlier than 2012-11-09 |
| 25 | 1.2.14 | Order Pegs and Fasteners | 1d | 2012-10-15 | 2012-10-15 | 17 | 51.5d | 0d | start no earlier than 2012-10-15 |
| 26 | 1.2.15 | Peg and Fastener Procurement | 18d? | 2012-10-16 | 2012-11-08 | 25 | 51.5d |  | start no earlier than 2012-09-25 |

| ID | WBS | Task | Duration | Start | Finish | Predecessors | Total slack | Free slack | Constraint |
| --- | --- | --- | --- | --- | --- | --- | --- | --- | --- |
| 27 | 1.3 | **Shop Work** | 32d? | 2012-10-29 | 2012-12-11 |  | 5.5d |  | start no earlier than 2012-08-08 |
| 28 | 1.3.1 | Timber Delivery | 1d | 2012-10-29 | 2012-10-29 | 19 | 59.5d |  | start no earlier than 2012-10-28 |
| 29 | 1.3.2 | Layout | 9d | 2012-10-30 | 2012-11-09 | 7 | 6d | 5d | start no earlier than 2012-10-30 |
| 30 | 1.3.3 | Cutting | 15d | 2012-11-05 | 2012-11-23 |  | 0.5d | 0d | start no earlier than 2012-11-05 |
| 31 | 1.3.4 | Peg and Fastener Delivery | 1d? | 2012-11-26 | 2012-11-26 |  | 9.5d | 9d | start no earlier than 2012-11-26 |
| 32 | 1.3.5 | Fit up | 5d | 2012-11-26 | 2012-11-30 | 30 | 0.5d | 0d | start no earlier than 2012-11-25 |
| 33 | 1.3.6 | Sanding | 5d | 2012-12-03 | 2012-12-07 | 32 | 0.5d | 0d | start no earlier than 2012-12-03 |
| 34 | 1.3.7 | Finishing | 14.5d | 2012-11-19 | 2012-12-07 | 29 | 1d | 0.5d | start no earlier than 2012-11-18 |
| 35 | 1.3.8 | Load Finished Timbers | 1d | 2012-12-10 | 2012-12-10 | 33, 34, 31 | 0.5d | 0d | start no earlier than 2012-12-10 |
| 36 | 1.3.9 | Load Tools for Raising | 1d | 2012-12-11 | 2012-12-11 | 35 | 0.5d | 0d | start no earlier than 2012-12-10 |
| 37 | 1.4 | **Site Work** | 25.5d? | 2012-12-12 | 2013-01-16 |  | 0.5d |  | start no earlier than 2012-08-08 |
| 38 | 1.4.1 | **Timber Frame** | 7d? | 2012-12-12 | 2012-12-20 |  | 0.5d |  | start no earlier than 2012-08-08 |
| 39 | 1.4.1.1 | Survey the subfloor and foundation | 0.5d? | 2012-12-12 | 2012-12-12 | 36 | 0.5d | 0d | start no earlier than 2012-12-11 |
| 40 | 1.4.1.2 | Unload Timbers | 1d | 2012-12-12 | 2012-12-13 | 39 | 0.5d | 0d | start no earlier than 2012-12-11 |
| 41 | 1.4.1.3 | Assembly | 2d | 2012-12-13 | 2012-12-17 | 40 | 0.5d | 0d | start no earlier than 2012-12-13 |
| 42 | 1.4.1.4 | Raising | 2d | 2012-12-17 | 2012-12-19 | 41 | 0.5d | 0d | start no earlier than 2012-12-16 |
| 43 | 1.4.1.5 | Check Frame | 1.5d | 2012-12-19 | 2012-12-20 | 42 | 0.5d | 0d | start no earlier than 2012-12-19 |
| 44 | 1.4.2 | **T&G Decking** | 3.5d? | 2012-12-21 | 2012-12-26 |  | 0.5d |  | start no earlier than 2012-08-08 |
| 45 | 1.4.2.1 | T&G Decking Install | 2.5d | 2012-12-21 | 2012-12-25 | 43, 21 | 0.5d | 0d | start no earlier than 2012-12-20 |
| 46 | 1.4.2.2 | Install Underlayment | 1d? | 2012-12-25 | 2012-12-26 | 45 | 0.5d | 0d | start no earlier than 2012-12-23 |
| 47 | 1.4.3 | **SIP Install** | 17.5d? | 2012-12-24 | 2013-01-16 |  | 2d |  | start no earlier than 2012-08-08 |
| 48 | 1.4.3.1 | SIP Delivery | 1d? | 2012-12-24 | 2012-12-24 | 23 | 2d | 1.5d | start no earlier than 2012-12-24 |
| 49 | 1.4.3.2 | Prep Panels | 2d? | 2012-12-26 | 2012-12-28 | 48, 46 | 0.5d | 0d | start no earlier than 2012-12-23 |
| 50 | 1.4.3.3 | Wall Panel Install | 5d? | 2012-12-28 | 2013-01-04 | 49 | 0.5d | 0d | start no earlier than 2012-12-26 |
| 51 | 1.4.3.4 | Roof Panel Install | 5d? | 2013-01-04 | 2013-01-11 | 50 | 0.5d | 0d | start no earlier than 2012-12-31 |
| 52 | 1.4.3.5 | Foaming | 1d? | 2013-01-11 | 2013-01-14 | 51 | 5d |  | start no earlier than 2013-01-07 |
| 53 | 1.4.3.6 | Install Underlayment | 2.5d? | 2013-01-14 | 2013-01-16 | 51 | 0d |  | start no earlier than 2013-01-13 |
| 54 | 2 | Punch List | 3d? | 2013-01-16 | 2013-01-21 | 53 | 0d |  | start no earlier than 2013-01-16 |
